# eLearning Project Plan

Schedule from MS Project, 2009-02-16 to 2009-04-14, costs in $.
mark steiner, inc.

## Calendars

- Standard: Mon-Fri 08:00-12:00, 13:00-17:00; Sat-Sun off.

## Resources

| Resource | Rate |
| --- | --- |
| WH_PM | 125 |
| Lotus_Buyer |  |
| Lotus_Acceptor |  |
| WH_ID_Sr | 125 |
| WH_Tech | 125 |
| WH_AD | 125 |
| Lotus_Reviewer1 |  |
| Lotus_Reviewer2 |  |
| Lotus_Reviewer3 |  |
| Lotus_Reviewer4 |  |
| Lotus_SME1 |  |
| Lotus_SME2 |  |
| Lotus_Usability1 |  |
| Lotus_Usability2 |  |
| Lotus_Beta Tester1 |  |
| Lotus_Beta Tester2 |  |
| WH_ID1 | 125 |
| WH_Author | 125 |
| WH_GD1 | 125 |
| WH_Edit1 | 125 |
| WH_Audio | 125 |
| WH_Talent | 125 |
| WH_Video | 125 |

## Schedule

| ID | WBS | Task | Type | Duration | Start | Finish | Predecessors | Baseline start | Baseline finish | Baseline duration | Total slack | Resources | Work | Cost |
| --- | --- | --- | --- | --- | --- | --- | --- | --- | --- | --- | --- | --- | --- | --- |
| 1 | 1 | **Lotus LearningSpace Sales Enablement Training** |  | 41.81d | 2009-02-16 08:00 | 2009-04-14 15:30 |  |  |  |  | 0d |  | 1222h | 99,875 |
| 2 | 1.1 | **Planning** |  | 1.88d | 2009-02-16 08:00 | 2009-02-17 16:00 |  | 1998-10-26 08:00 | 1998-10-26 17:00 | 1d | 0d |  | 35h | 3,375 |
| 3 | 1.1.1 | Identify WH team members |  | 8h | 2009-02-16 08:00 | 2009-02-16 17:00 |  | 1998-10-26 08:00 | 1998-10-26 17:00 | 1d | 0d | WH_PM | 8h | 1,000 |
| 4 | 1.1.2 | **Identify client team members** |  | 0d | 2009-02-16 08:00 | 2009-02-16 08:00 |  | 1998-10-26 08:00 | 1998-10-26 17:00 | 1d | 41.81d |  |  |  |
| 5 | 1.1.2.1 | Buyer | milestone | 0h | 2009-02-16 08:00 | 2009-02-16 08:00 |  | 1998-10-26 08:00 | 1998-10-26 17:00 | 1d | 41.81d |  |  |  |
| 6 | 1.1.2.2 | Acceptor | milestone | 0h | 2009-02-16 08:00 | 2009-02-16 08:00 |  | 1998-10-26 08:00 | 1998-10-26 17:00 | 1d | 41.81d |  |  |  |
| 7 | 1.1.2.3 | SME's | milestone | 0h | 2009-02-16 08:00 | 2009-02-16 08:00 |  | 1998-10-26 08:00 | 1998-10-26 17:00 | 1d | 41.81d |  |  |  |
| 8 | 1.1.2.4 | Reviewers | milestone | 0h | 2009-02-16 08:00 | 2009-02-16 08:00 |  | 1998-10-26 08:00 | 1998-10-26 17:00 | 1d | 41.81d |  |  |  |
| 9 | 1.1.2.5 | Usability testers | milestone | 0h | 2009-02-16 08:00 | 2009-02-16 08:00 |  | 1998-10-26 08:00 | 1998-10-26 17:00 | 1d | 41.81d |  |  |  |
| 10 | 1.1.2.6 | Beta testers | milestone | 0h | 2009-02-16 08:00 | 2009-02-16 08:00 |  | 1998-10-26 08:00 | 1998-10-26 17:00 | 1d | 41.81d |  |  |  |
| 11 | 1.1.3 | Create Project Control File |  | 1h | 2009-02-17 08:00 | 2009-02-17 09:00 | 3 | 1998-10-26 08:00 | 1998-10-26 17:00 | 1d | 0d | WH_PM | 1h | 125 |
| 12 | 1.1.4 | Distribute proposal | milestone | 0h | 2009-02-17 09:00 | 2009-02-17 09:00 | 11 | 1998-10-26 08:00 | 1998-10-26 17:00 | 1d | 0d | WH_PM |  |  |
| 13 | 1.1.5 | Conduct internal kickoff meeting |  | 2h | 2009-02-17 09:00 | 2009-02-17 11:00 | 12 | 1998-10-26 08:00 | 1998-10-26 17:00 | 1d | 0d | WH_PM; WH_ID_Sr; WH_AD | 6h | 750 |
| 14 | 1.1.6 | Conduct client kickoff meeting |  | 4h | 2009-02-17 11:00 | 2009-02-17 16:00 | 13 | 1998-10-26 08:00 | 1998-10-26 17:00 | 1d | 0d | WH_PM; Lotus_Buyer; Lotus_Acceptor; WH_ID_Sr; WH_AD | 20h | 1,500 |
| 15 | 1.2 | **Analysis** |  | 7.06d | 2009-02-16 17:00 | 2009-02-26 08:30 |  | 1998-10-26 08:00 | 1998-10-26 17:00 | 1d | 0.88d |  | 139h | 11,125 |
| 16 | 1.2.1 | Lotus delivers all existing content resources for training (documentation, Freelance presentations, ScreenCams, etc.) | milestone | 0h | 2009-02-16 17:00 | 2009-02-16 17:00 | 3 | 1998-10-26 08:00 | 1998-10-26 17:00 | 1d | 40.81d | Lotus_SME1 |  |  |
| 17 | 1.2.2 | Review existing content resources |  | 4h | 2009-02-17 16:00 | 2009-02-18 11:00 | 14 | 1998-10-26 08:00 | 1998-10-26 17:00 | 1d | 0d | WH_PM | 4h | 500 |
| 18 | 1.2.3 | Revise content outline |  | 12h | 2009-02-18 11:00 | 2009-02-19 16:00 | 17 | 1998-10-26 08:00 | 1998-10-26 17:00 | 1d | 0d | WH_PM | 12h | 1,500 |
| 19 | 1.2.4 | **Perform audience analysis** |  | 0.25d | 2009-02-19 16:00 | 2009-02-20 09:00 |  | 1998-10-26 08:00 | 1998-10-26 17:00 | 1d | 0d |  | 2h | 250 |
| 20 | 1.2.4.1 | Identify general characteristics | milestone | 0h | 2009-02-19 16:00 | 2009-02-19 16:00 | 18 | 1998-10-26 08:00 | 1998-10-26 17:00 | 1d | 0d | WH_PM |  |  |
| 21 | 1.2.4.2 | Perform motivation analysis |  | 2h | 2009-02-19 16:00 | 2009-02-20 09:00 | 20 | 1998-10-26 08:00 | 1998-10-26 17:00 | 1d | 0d | WH_PM | 2h | 250 |
| 22 | 1.2.5 | **Perform training environment analysis** |  | 0.25d | 2009-02-20 09:00 | 2009-02-20 11:00 |  | 1998-10-26 08:00 | 1998-10-26 17:00 | 1d | 0d |  | 2h | 250 |
| 23 | 1.2.5.1 | Analyze infrastructure fo training delivery |  | 2h | 2009-02-20 09:00 | 2009-02-20 11:00 | 21 | 1998-10-26 08:00 | 1998-10-26 17:00 | 1d | 0d | WH_PM | 2h | 250 |
| 24 | 1.2.6 | **Analysis working session** |  | 1.44d | 2009-02-20 11:00 | 2009-02-23 15:30 |  | 1998-10-26 08:00 | 1998-10-26 17:00 | 1d | 0d |  | 41h | 2,875 |
| 25 | 1.2.6.1 | Validate business needs | milestone | 0h | 2009-02-20 11:00 | 2009-02-20 11:00 | 23 | 1998-10-26 08:00 | 1998-10-26 17:00 | 1d | 0d | WH_PM; Lotus_Acceptor; WH_ID_Sr; Lotus_SME1 |  |  |
| 26 | 1.2.6.2 | Validate alignment of business and training needs | milestone | 0h | 2009-02-20 11:00 | 2009-02-20 11:00 | 25 | 1998-10-26 08:00 | 1998-10-26 17:00 | 1d | 0d | WH_PM; Lotus_Acceptor; WH_ID_Sr; Lotus_SME1 |  |  |
| 27 | 1.2.6.3 | Complete training goal analysis | milestone | 0h | 2009-02-20 11:00 | 2009-02-20 11:00 | 26 | 1998-10-26 08:00 | 1998-10-26 17:00 | 1d | 0d | WH_PM; Lotus_Acceptor; WH_ID_Sr; Lotus_SME1 |  |  |
| 28 | 1.2.6.4 | Specify/validate audience | milestone | 0h | 2009-02-20 11:00 | 2009-02-20 11:00 | 27 | 1998-10-26 08:00 | 1998-10-26 17:00 | 1d | 0d | WH_PM; Lotus_Acceptor; WH_ID_Sr; Lotus_SME1 |  |  |
| 29 | 1.2.6.5 | Specify knowledge and skills required in training |  | 1h | 2009-02-20 11:00 | 2009-02-20 12:00 | 28 | 1998-10-26 08:00 | 1998-10-26 17:00 | 1d | 0d | WH_PM; Lotus_Acceptor; WH_ID_Sr; Lotus_SME1 | 4h | 250 |
| 30 | 1.2.6.6 | Organize knowledge and skills into courses |  | 0.5h | 2009-02-20 13:00 | 2009-02-20 13:30 | 29 | 1998-10-26 08:00 | 1998-10-26 17:00 | 1d | 0d | WH_PM; Lotus_Acceptor; WH_ID_Sr; Lotus_SME1 | 2h | 125 |
| 31 | 1.2.6.7 | Specify the modules in each course |  | 0.5h | 2009-02-20 13:30 | 2009-02-20 14:00 | 30 | 1998-10-26 08:00 | 1998-10-26 17:00 | 1d | 0d | WH_PM; Lotus_Acceptor; WH_ID_Sr; Lotus_SME1 | 2h | 125 |
| 32 | 1.2.6.8 | Specify the lessons in each module |  | 1h | 2009-02-20 14:00 | 2009-02-20 15:00 | 31 | 1998-10-26 08:00 | 1998-10-26 17:00 | 1d | 0d | WH_PM; Lotus_Acceptor; WH_ID_Sr; Lotus_SME1 | 4h | 250 |
| 33 | 1.2.6.9 | Specify the learning objectives in each lesson |  | 1h | 2009-02-20 15:00 | 2009-02-20 16:00 | 32 | 1998-10-26 08:00 | 1998-10-26 17:00 | 1d | 0d | WH_PM; Lotus_Acceptor; WH_ID_Sr; Lotus_SME1 | 4h | 250 |
| 34 | 1.2.6.10 | At a high-level, specify learning activities in each lesson |  | 4h | 2009-02-20 16:00 | 2009-02-23 11:00 | 33 | 1998-10-26 08:00 | 1998-10-26 17:00 | 1d | 0d | WH_PM; Lotus_Acceptor; WH_ID_Sr; Lotus_SME1 | 16h | 1,000 |
| 35 | 1.2.6.11 | Brainstorm a metaphor designed to provide focus (Intros, transitions, motivational elements, etc.) |  | 1h | 2009-02-23 11:00 | 2009-02-23 12:00 | 34 | 1998-10-26 08:00 | 1998-10-26 17:00 | 1d | 0d | WH_PM; Lotus_Acceptor; WH_ID_Sr; Lotus_SME1 | 4h | 250 |
| 36 | 1.2.6.12 | Select appropriate combination of training solutions/media |  | 2h | 2009-02-23 13:00 | 2009-02-23 15:00 | 35 | 1998-10-26 08:00 | 1998-10-26 17:00 | 1d | 0d | WH_PM; WH_ID_Sr | 4h | 500 |
| 37 | 1.2.6.13 | Specify appropriate tools for design/construction/testing |  | 0.5h | 2009-02-23 15:00 | 2009-02-23 15:30 | 36 | 1998-10-26 08:00 | 1998-10-26 17:00 | 1d | 0d | WH_PM; WH_ID_Sr | 1h | 125 |

| ID | WBS | Task | Type | Duration | Start | Finish | Predecessors | Baseline start | Baseline finish | Baseline duration | Total slack | Free slack | Resources | Work | Cost |
| --- | --- | --- | --- | --- | --- | --- | --- | --- | --- | --- | --- | --- | --- | --- | --- |
| 38 | 1.2.7 | **Revise Project Definition** |  | 2.06d | 2009-02-23 13:00 | 2009-02-25 13:30 |  | 1998-10-26 08:00 | 1998-10-26 17:00 | 1d | 0.31d |  |  | 40h | 5,000 |
| 39 | 1.2.7.1 | Instructional Design for asynchronous (self-paced) training |  | 12h | 2009-02-23 15:30 | 2009-02-25 10:30 | 37 | 1998-10-26 08:00 | 1998-10-26 17:00 | 1d | 34.25d | 0d | WH_ID_Sr; WH_PM | 24h | 3,000 |
| 40 | 1.2.7.2 | Instructional Design for asynchronous (collaborative) training |  | 2h | 2009-02-25 10:30 | 2009-02-25 13:30 | 39 | 1998-10-26 08:00 | 1998-10-26 17:00 | 1d | 34.25d | 0d | WH_ID_Sr; WH_PM | 4h | 500 |
| 41 | 1.2.7.3 | Instructional Design for synchronous (live) training | milestone | 0h | 2009-02-25 13:30 | 2009-02-25 13:30 | 40 | 1998-10-26 08:00 | 1998-10-26 17:00 | 1d | 34.25d |  | WH_ID_Sr; WH_PM |  |  |
| 42 | 1.2.7.4 | Graphic Design for all training |  | 8h | 2009-02-23 13:00 | 2009-02-24 12:00 | 35 | 1998-10-26 08:00 | 1998-10-26 17:00 | 1d | 35.31d |  | WH_AD | 8h | 1,000 |
| 43 | 1.2.7.5 | Technical Design (functional requirements specification) |  | 4h | 2009-02-23 15:30 | 2009-02-24 10:30 | 37 | 1998-10-26 08:00 | 1998-10-26 17:00 | 1d | 0d |  | WH_PM | 4h | 500 |
| 44 | 1.2.8 | **Revise Project Plan** |  | 0.75d | 2009-02-24 10:30 | 2009-02-25 08:30 |  | 1998-10-26 08:00 | 1998-10-26 17:00 | 1d | 0d |  |  | 6h | 750 |
| 45 | 1.2.8.1 | Structured Work Breakdown |  | 4h | 2009-02-24 10:30 | 2009-02-24 15:30 | 43 | 1998-10-26 08:00 | 1998-10-26 17:00 | 1d | 0d |  | WH_PM | 4h | 500 |
| 46 | 1.2.8.2 | Organization and staffing |  | 1h | 2009-02-24 15:30 | 2009-02-24 16:30 | 45 | 1998-10-26 08:00 | 1998-10-26 17:00 | 1d | 0d |  | WH_PM | 1h | 125 |
| 47 | 1.2.8.3 | Budget |  | 1h | 2009-02-24 16:30 | 2009-02-25 08:30 | 46 | 1998-10-26 08:00 | 1998-10-26 17:00 | 1d | 0d |  | WH_PM | 1h | 125 |
| 48 | 1.2.9 | Deliver revised Project Definition & Project Plan | milestone | 0h | 2009-02-25 08:30 | 2009-02-25 08:30 | 47 | 1998-10-26 08:00 | 1998-10-26 17:00 | 1d | 0d |  | WH_PM |  |  |
| 49 | 1.2.10 | Lotus reviews & approves Project Definition & Project Plan |  | 8h | 2009-02-25 08:30 | 2009-02-26 08:30 | 48 | 1998-10-26 08:00 | 1998-10-26 17:00 | 1d | 33.75d |  | Lotus_Buyer; Lotus_Acceptor; Lotus_Reviewer1; Lotus_SME1 | 32h |  |
| 50 | 1.3 | **Design and Prototype Initial Course** |  | 16.56d | 2009-02-16 08:00 | 2009-03-10 13:30 |  | 1998-10-26 08:00 | 1998-10-26 17:00 | 1d | 7.06d |  |  | 228h | 17,625 |
| 51 | 1.3.1 | **Develop Detailed Design Document** |  | 8.56d | 2009-02-16 08:00 | 2009-02-26 13:30 |  | 1998-10-26 08:00 | 1998-10-26 17:00 | 1d | 7.06d |  |  | 24h | 3,000 |
| 52 | 1.3.1.1 | Specifiy learning activities for asynchronous (self-paced) learning |  | 10h | 2009-02-25 08:30 | 2009-02-26 10:30 | 48 | 1998-10-26 08:00 | 1998-10-26 17:00 | 1d | 0d |  | WH_ID_Sr; WH_PM | 20h | 2,500 |
| 53 | 1.3.1.2 | **Learning activities for self-paced learning may include** |  | 0d | 2009-02-16 08:00 | 2009-02-16 08:00 |  | 1998-10-26 08:00 | 1998-10-26 17:00 | 1d | 41.81d |  |  |  |  |
| 54 | 1.3.1.2.1 | Gain attention and motivate learner | milestone | 0h | 2009-02-16 08:00 | 2009-02-16 08:00 |  | 1998-10-26 08:00 | 1998-10-26 17:00 | 1d | 41.81d |  |  |  |  |
| 55 | 1.3.1.2.2 | Inform learner of the objectives | milestone | 0h | 2009-02-16 08:00 | 2009-02-16 08:00 |  | 1998-10-26 08:00 | 1998-10-26 17:00 | 1d | 41.81d |  |  |  |  |
| 56 | 1.3.1.2.3 | Recall prerequisite learning | milestone | 0h | 2009-02-16 08:00 | 2009-02-16 08:00 |  | 1998-10-26 08:00 | 1998-10-26 17:00 | 1d | 41.81d |  |  |  |  |
| 57 | 1.3.1.2.4 | Inform learner of required skills | milestone | 0h | 2009-02-16 08:00 | 2009-02-16 08:00 |  | 1998-10-26 08:00 | 1998-10-26 17:00 | 1d | 41.81d |  |  |  |  |
| 58 | 1.3.1.2.5 | Present content | milestone | 0h | 2009-02-16 08:00 | 2009-02-16 08:00 |  | 1998-10-26 08:00 | 1998-10-26 17:00 | 1d | 41.81d |  |  |  |  |
| 59 | 1.3.1.2.6 | Elaborate content | milestone | 0h | 2009-02-16 08:00 | 2009-02-16 08:00 |  | 1998-10-26 08:00 | 1998-10-26 17:00 | 1d | 41.81d |  |  |  |  |
| 60 | 1.3.1.2.7 | Provide learning guidance | milestone | 0h | 2009-02-16 08:00 | 2009-02-16 08:00 |  | 1998-10-26 08:00 | 1998-10-26 17:00 | 1d | 41.81d |  |  |  |  |
| 61 | 1.3.1.2.8 | Provide practice | milestone | 0h | 2009-02-16 08:00 | 2009-02-16 08:00 |  | 1998-10-26 08:00 | 1998-10-26 17:00 | 1d | 41.81d |  |  |  |  |
| 62 | 1.3.1.2.9 | Provide feedback | milestone | 0h | 2009-02-16 08:00 | 2009-02-16 08:00 |  | 1998-10-26 08:00 | 1998-10-26 17:00 | 1d | 41.81d |  |  |  |  |
| 63 | 1.3.1.2.10 | Assess performance | milestone | 0h | 2009-02-16 08:00 | 2009-02-16 08:00 |  | 1998-10-26 08:00 | 1998-10-26 17:00 | 1d | 41.81d |  |  |  |  |
| 64 | 1.3.1.2.11 | Provide remediation or enrichment | milestone | 0h | 2009-02-16 08:00 | 2009-02-16 08:00 |  | 1998-10-26 08:00 | 1998-10-26 17:00 | 1d | 41.81d |  |  |  |  |
| 65 | 1.3.1.2.12 | Enhance retention and transfer | milestone | 0h | 2009-02-16 08:00 | 2009-02-16 08:00 |  | 1998-10-26 08:00 | 1998-10-26 17:00 | 1d | 41.81d |  |  |  |  |
| 66 | 1.3.1.3 | Specify learning activities for asynchronous (collaborative) learning |  | 2h | 2009-02-26 10:30 | 2009-02-26 13:30 | 52 | 1998-10-26 08:00 | 1998-10-26 17:00 | 1d | 0d |  | WH_ID_Sr; WH_PM | 4h | 500 |
| 67 | 1.3.1.4 | Specify learning activities for synchronous (live) learning | milestone | 0h | 2009-02-26 13:30 | 2009-02-26 13:30 | 66 | 1998-10-26 08:00 | 1998-10-26 17:00 | 1d | 0d |  | WH_ID_Sr; WH_PM |  |  |

| ID | WBS | Task | Type | Duration | Start | Finish | Predecessors | Baseline start | Baseline finish | Baseline duration | Total slack | Free slack | Resources | Work | Cost |
| --- | --- | --- | --- | --- | --- | --- | --- | --- | --- | --- | --- | --- | --- | --- | --- |
| 68 | 1.3.2 | **Rapid prototyping** |  | 7.25d | 2009-02-26 13:30 | 2009-03-09 15:30 |  | 1998-10-26 08:00 | 1998-10-26 17:00 | 1d | 0d |  |  | 157h | 11,750 |
| 69 | 1.3.2.1 | **Rapid prototyping process** |  | 7.25d | 2009-02-26 13:30 | 2009-03-09 15:30 |  | 1998-10-26 08:00 | 1998-10-26 17:00 | 1d | 0d |  |  | 157h | 11,750 |
| 70 | 1.3.2.1.1 | **Cycle 1** |  | 5.5d | 2009-02-26 13:30 | 2009-03-06 08:30 |  |  |  |  | 0d |  |  | 114h | 9,125 |
| 71 | 1.3.2.1.1.1 | Develop/synthesize content for asynchronous (self-paced) learning activities |  | 16h | 2009-02-26 13:30 | 2009-03-02 13:30 | 67 | 1998-10-26 08:00 | 1998-10-26 17:00 | 1d | 30.75d | 0d | WH_ID_Sr; Lotus_SME1 | 32h | 2,000 |
| 72 | 1.3.2.1.1.2 | Develop/synthesize content for asynchronous (collaborative) learning activities |  | 4h | 2009-03-02 13:30 | 2009-03-03 08:30 | 71 | 1998-10-26 08:00 | 1998-10-26 17:00 | 1d | 30.75d | 0d | WH_ID_Sr; Lotus_SME1 | 8h | 500 |
| 73 | 1.3.2.1.1.3 | Develop/synthesize content for synchronous (live) learning activities | milestone | 0h | 2009-03-03 08:30 | 2009-03-03 08:30 | 72 | 1998-10-26 08:00 | 1998-10-26 17:00 | 1d | 30.75d |  | WH_ID_Sr; Lotus_SME1 |  |  |
| 74 | 1.3.2.1.1.4 | **Produce/repurpose multimedia elements** |  | 2.5d | 2009-02-26 13:30 | 2009-03-03 08:30 |  | 1998-10-26 08:00 | 1998-10-26 17:00 | 1d | 0d |  |  | 42h | 3,500 |
| 75 | 1.3.2.1.1.4.1 | Produce/repurpose interactive elements |  | 8h | 2009-02-26 13:30 | 2009-02-27 13:30 | 67 | 1998-10-26 08:00 | 1998-10-26 17:00 | 1d | 0d |  | Lotus_SME1 [50%]; WH_PM | 12h | 1,000 |
| 76 | 1.3.2.1.1.4.2 | Produce/repurpose ScreenCam elements | milestone | 0h | 2009-02-27 13:30 | 2009-02-27 13:30 | 75 | 1998-10-26 08:00 | 1998-10-26 17:00 | 1d | 0d |  | Lotus_SME1 [50%]; WH_PM |  |  |
| 77 | 1.3.2.1.1.4.3 | Produce/repurpose graphic elements |  | 8h | 2009-02-27 13:30 | 2009-03-02 13:30 | 76 | 1998-10-26 08:00 | 1998-10-26 17:00 | 1d | 31.25d |  | Lotus_SME1 [50%]; WH_AD | 12h | 1,000 |
| 78 | 1.3.2.1.1.4.4 | Produce/repurpose audio elements |  | 4h | 2009-02-27 13:30 | 2009-03-02 08:30 | 76 | 1998-10-26 08:00 | 1998-10-26 17:00 | 1d | 0d |  | Lotus_SME1 [50%]; WH_PM | 6h | 500 |
| 79 | 1.3.2.1.1.4.5 | Produce/repurpose video elements |  | 8h | 2009-03-02 08:30 | 2009-03-03 08:30 | 78 | 1998-10-26 08:00 | 1998-10-26 17:00 | 1d | 0d |  | Lotus_SME1 [50%]; WH_PM | 12h | 1,000 |
| 80 | 1.3.2.1.1.5 | Author course components for asynchronous (self-paced) learning activities |  | 16h | 2009-03-03 08:30 | 2009-03-05 08:30 | 79 | 1998-10-26 08:00 | 1998-10-26 17:00 | 1d | 0d |  | WH_PM | 16h | 2,000 |
| 81 | 1.3.2.1.1.6 | Author course components for asynchronous (collaborative) learning activities |  | 2h | 2009-03-05 08:30 | 2009-03-05 10:30 | 80 | 1998-10-26 08:00 | 1998-10-26 17:00 | 1d | 0d |  | WH_PM | 2h | 250 |
| 82 | 1.3.2.1.1.7 | Author course components for synchronous (live) learning activities | milestone | 0h | 2009-03-05 10:30 | 2009-03-05 10:30 | 81 | 1998-10-26 08:00 | 1998-10-26 17:00 | 1d | 0d |  | WH_PM |  |  |
| 83 | 1.3.2.1.1.8 | Test on client specified platform |  | 4h | 2009-03-05 10:30 | 2009-03-05 15:30 | 82 | 1998-10-26 08:00 | 1998-10-26 17:00 | 1d | 0d |  | WH_PM | 4h | 500 |
| 84 | 1.3.2.1.1.9 | Review prototype with users |  | 1h | 2009-03-05 15:30 | 2009-03-05 16:30 | 83 | 1998-10-26 08:00 | 1998-10-26 17:00 | 1d | 26d | 0d | WH_ID_Sr; Lotus_Usability1 | 2h | 125 |
| 85 | 1.3.2.1.1.10 | Review prototype with client |  | 2h | 2009-03-05 15:30 | 2009-03-06 08:30 | 83 | 1998-10-26 08:00 | 1998-10-26 17:00 | 1d | 0d |  | Lotus_Acceptor; Lotus_Reviewer1; Lotus_SME1; WH_PM | 8h | 250 |
| 86 | 1.3.2.1.2 | **Cycle 2** |  | 1.88d | 2009-03-05 16:30 | 2009-03-09 15:30 |  |  |  |  | 0.12d |  |  | 43h | 2,625 |
| 87 | 1.3.2.1.2.1 | Revise instructional design for asynchronous (self-paced) learning activities |  | 4h | 2009-03-05 16:30 | 2009-03-06 11:30 | 84 | 1998-10-26 08:00 | 1998-10-26 17:00 | 1d | 26d | 0d | WH_ID_Sr; Lotus_SME1 | 8h | 500 |
| 88 | 1.3.2.1.2.2 | Revise instructional design for asynchronous (collaborative) learning activities |  | 0.5h | 2009-03-06 11:30 | 2009-03-06 12:00 | 87 | 1998-10-26 08:00 | 1998-10-26 17:00 | 1d | 26d | 0d | WH_ID_Sr; Lotus_SME1 | 1h | 62.5 |
| 89 | 1.3.2.1.2.3 | Revise instructional design for synchronous (live) learning activities |  | 0.5h | 2009-03-06 13:00 | 2009-03-06 13:30 | 88 | 1998-10-26 08:00 | 1998-10-26 17:00 | 1d | 26d | 0d | WH_ID_Sr; Lotus_SME1 | 1h | 62.5 |
| 90 | 1.3.2.1.2.4 | Revise content for asynchronous (self-paced) learning activities |  | 8h | 2009-03-06 13:30 | 2009-03-09 13:30 | 89 | 1998-10-26 08:00 | 1998-10-26 17:00 | 1d | 26d | 0d | WH_ID_Sr; Lotus_SME1 | 16h | 1,000 |
| 91 | 1.3.2.1.2.5 | Revise content for asynchronous (collaborative) learning activities |  | 2h | 2009-03-09 13:30 | 2009-03-09 15:30 | 90 | 1998-10-26 08:00 | 1998-10-26 17:00 | 1d | 26d | 0d | WH_ID_Sr; Lotus_SME1 | 4h | 250 |
| 92 | 1.3.2.1.2.6 | Revise content for synchronous (live) learning activities | milestone | 0h | 2009-03-09 15:30 | 2009-03-09 15:30 | 91 | 1998-10-26 08:00 | 1998-10-26 17:00 | 1d | 26d |  | WH_ID_Sr; Lotus_SME1 |  |  |
| 93 | 1.3.2.1.2.7 | Revise course components for asynchronous (self-paced) learning activities |  | 2h | 2009-03-06 08:30 | 2009-03-06 10:30 | 85 | 1998-10-26 08:00 | 1998-10-26 17:00 | 1d | 0d |  | WH_PM | 2h | 250 |
| 94 | 1.3.2.1.2.8 | Revise course components for asynchronous (collaborative) learning activities |  | 1h | 2009-03-06 10:30 | 2009-03-06 11:30 | 93 | 1998-10-26 08:00 | 1998-10-26 17:00 | 1d | 0d |  | WH_PM | 1h | 125 |
| 95 | 1.3.2.1.2.9 | Revise course components for synchronous (live) learning activities | milestone | 0h | 2009-03-06 11:30 | 2009-03-06 11:30 | 94 | 1998-10-26 08:00 | 1998-10-26 17:00 | 1d | 0d |  | WH_PM |  |  |
| 96 | 1.3.2.1.2.10 | Review prototype with users |  | 1h | 2009-03-06 11:30 | 2009-03-06 13:30 | 95 | 1998-10-26 08:00 | 1998-10-26 17:00 | 1d | 27d | 0d | WH_ID_Sr; Lotus_Usability1 | 2h | 125 |
| 97 | 1.3.2.1.2.11 | Review prototype with client |  | 2h | 2009-03-06 11:30 | 2009-03-06 14:30 | 95 | 1998-10-26 08:00 | 1998-10-26 17:00 | 1d | 0d |  | Lotus_Acceptor; Lotus_Reviewer1; Lotus_SME1; WH_PM | 8h | 250 |
| 98 | 1.3.2.1.2.12 | Client approves prototype | milestone | 0h | 2009-03-06 14:30 | 2009-03-06 14:30 | 97 | 1998-10-26 08:00 | 1998-10-26 17:00 | 1d | 25.62d | 0d | Lotus_Acceptor; Lotus_Reviewer1; Lotus_SME1 |  |  |

| ID | WBS | Task | Type | Duration | Start | Finish | Predecessors | Baseline start | Baseline finish | Baseline duration | Total slack | Free slack | Resources | Work | Cost |
| --- | --- | --- | --- | --- | --- | --- | --- | --- | --- | --- | --- | --- | --- | --- | --- |
| 99 | 1.3.3 | **Revise and approve Detailed Design Document** |  | 1.12d | 2009-03-06 14:30 | 2009-03-09 15:30 |  | 1998-10-26 08:00 | 1998-10-26 17:00 | 1d | 0d |  |  | 33h | 1,125 |
| 100 | 1.3.3.1 | Revise learning activities for asynchronous (self-paced) learning |  | 8h | 2009-03-06 14:30 | 2009-03-09 14:30 | 97 | 1998-10-26 08:00 | 1998-10-26 17:00 | 1d | 0d |  | WH_PM | 8h | 1,000 |
| 101 | 1.3.3.2 | Revise learning activities for asynchronous (collaborative) learning |  | 1h | 2009-03-09 14:30 | 2009-03-09 15:30 | 100 | 1998-10-26 08:00 | 1998-10-26 17:00 | 1d | 0d |  | WH_PM | 1h | 125 |
| 102 | 1.3.3.3 | Revise learning activities for synchronous (live) learning | milestone | 0h | 2009-03-09 15:30 | 2009-03-09 15:30 | 101 | 1998-10-26 08:00 | 1998-10-26 17:00 | 1d | 0d |  | WH_PM |  |  |
| 103 | 1.3.3.4 | Deliver Detailed Design Document to client | milestone | 0h | 2009-03-09 15:30 | 2009-03-09 15:30 | 102 | 1998-10-26 08:00 | 1998-10-26 17:00 | 1d | 0d |  | WH_PM |  |  |
| 104 | 1.3.3.5 | Client approves final Project Definition Document |  | 8h | 2009-03-06 14:30 | 2009-03-09 14:30 | 98 | 1998-10-26 08:00 | 1998-10-26 17:00 | 1d | 25.62d | 0d | Lotus_Acceptor; Lotus_Reviewer1; Lotus_SME1 | 24h |  |
| 105 | 1.3.4 | **Create templates for course construction** |  | 1.75d | 2009-03-06 13:30 | 2009-03-10 10:30 |  | 1998-10-26 08:00 | 1998-10-26 17:00 | 1d | 1.25d |  |  | 5h | 625 |
| 106 | 1.3.4.1 | Create storyboarding templates |  | 4h | 2009-03-09 15:30 | 2009-03-10 10:30 | 103 | 1998-10-26 08:00 | 1998-10-26 17:00 | 1d | 0d |  | WH_PM | 4h | 500 |
| 107 | 1.3.4.2 | Select presentation templates for consistency |  | 1h | 2009-03-09 14:30 | 2009-03-09 15:30 | 104 | 1998-10-26 08:00 | 1998-10-26 17:00 | 1d | 25.62d | 0d | WH_AD | 1h | 125 |
| 108 | 1.3.4.3 | Create Participant's Guide documentation template | milestone | 0h | 2009-03-06 13:30 | 2009-03-06 13:30 | 96 | 1998-10-26 08:00 | 1998-10-26 17:00 | 1d | 27d | 0d | WH_ID_Sr |  |  |
| 109 | 1.3.4.4 | Create Instructor's Guide documentation template | milestone | 0h | 2009-03-06 13:30 | 2009-03-06 13:30 | 108 | 1998-10-26 08:00 | 1998-10-26 17:00 | 1d | 27d | 0d | WH_ID_Sr |  |  |
| 110 | 1.3.4.5 | Create Train-the-trainer documentation template | milestone | 0h | 2009-03-06 13:30 | 2009-03-06 13:30 | 109 | 1998-10-26 08:00 | 1998-10-26 17:00 | 1d | 27d | 0d | WH_ID_Sr |  |  |
| 111 | 1.3.5 | **Develop standards for constructing and updating course** |  | 2d | 2009-03-06 13:30 | 2009-03-10 13:30 |  | 1998-10-26 08:00 | 1998-10-26 17:00 | 1d | 25.25d |  |  | 9h | 1,125 |
| 112 | 1.3.5.1 | Construction standards for content |  | 1h | 2009-03-06 13:30 | 2009-03-06 14:30 | 110 | 1998-10-26 08:00 | 1998-10-26 17:00 | 1d | 27d | 0d | WH_ID_Sr | 1h | 125 |
| 113 | 1.3.5.2 | Style standards for writing and editing |  | 1h | 2009-03-06 14:30 | 2009-03-06 15:30 | 112 | 1998-10-26 08:00 | 1998-10-26 17:00 | 1d | 27d |  | WH_ID_Sr | 1h | 125 |
| 114 | 1.3.5.3 | Construction standards for graphic elements |  | 1h | 2009-03-09 15:30 | 2009-03-09 16:30 | 107 | 1998-10-26 08:00 | 1998-10-26 17:00 | 1d | 25.62d | 0d | WH_AD | 1h | 125 |
| 115 | 1.3.5.4 | Construction standards for presentations |  | 2h | 2009-03-09 16:30 | 2009-03-10 09:30 | 114 | 1998-10-26 08:00 | 1998-10-26 17:00 | 1d | 25.62d |  | WH_AD | 2h | 250 |
| 116 | 1.3.5.5 | Production standards for audio |  | 1h | 2009-03-09 14:30 | 2009-03-09 15:30 | 104 | 1998-10-26 08:00 | 1998-10-26 17:00 | 1d | 25.88d | 0d | WH_Audio | 1h | 125 |
| 117 | 1.3.5.6 | Production standards for video |  | 1h | 2009-03-09 15:30 | 2009-03-09 16:30 | 116 | 1998-10-26 08:00 | 1998-10-26 17:00 | 1d | 25.88d |  | WH_Audio | 1h | 125 |
| 118 | 1.3.5.7 | Construction standards for ScreenCam elements | milestone | 0h | 2009-03-10 10:30 | 2009-03-10 10:30 | 106 | 1998-10-26 08:00 | 1998-10-26 17:00 | 1d | 25.25d | 0d | WH_ID_Sr |  |  |
| 119 | 1.3.5.8 | Construction standards for asynchronous (self-paced) components |  | 1h | 2009-03-10 10:30 | 2009-03-10 11:30 | 118 | 1998-10-26 08:00 | 1998-10-26 17:00 | 1d | 25.25d | 0d | WH_ID_Sr | 1h | 125 |
| 120 | 1.3.5.9 | Construction standards for asynchronous (collaborative) components |  | 1h | 2009-03-10 11:30 | 2009-03-10 13:30 | 119 | 1998-10-26 08:00 | 1998-10-26 17:00 | 1d | 25.25d | 0d | WH_ID_Sr | 1h | 125 |
| 121 | 1.3.5.10 | Construction standards for synchronous (live) components | milestone | 0h | 2009-03-10 13:30 | 2009-03-10 13:30 | 120 | 1998-10-26 08:00 | 1998-10-26 17:00 | 1d | 25.25d |  | WH_ID_Sr |  |  |
| 122 | 1.4 | **Construction** |  | 15.5d | 2009-03-10 10:30 | 2009-03-31 15:30 |  |  |  |  | 0d |  |  | 687h | 55,125 |
| 123 | 1.4.1 | **Prepare for Construction** |  | 1d | 2009-03-10 10:30 | 2009-03-11 10:30 |  | 1998-10-26 08:00 | 1998-10-26 17:00 | 1d | 0d |  |  | 40h | 3,000 |
| 124 | 1.4.1.1 | Content construction walk-through |  | 8h | 2009-03-10 10:30 | 2009-03-11 10:30 | 106 | 1998-10-26 08:00 | 1998-10-26 17:00 | 1d | 0d |  | WH_PM; WH_ID_Sr; WH_AD; Lotus_Acceptor; Lotus_SME1 | 40h | 3,000 |

| ID | WBS | Task | Duration | Start | Finish | Predecessors | Baseline start | Baseline finish | Baseline duration | Total slack | Free slack | Resources | Work | Cost |
| --- | --- | --- | --- | --- | --- | --- | --- | --- | --- | --- | --- | --- | --- | --- |
| 125 | 1.4.2 | **Repurpose/construct text for asynchronous (self-paced) courses** | 8.5d | 2009-03-11 10:30 | 2009-03-23 15:30 |  |  |  |  | 0d |  |  | 312h | 17,250 |
| 126 | 1.4.2.1 | **Lesson 1: Course Introduction** | 1d | 2009-03-11 10:30 | 2009-03-12 10:30 |  | 1998-10-26 08:00 | 1998-10-26 17:00 | 1d | 0d |  |  | 19h | 1,375 |
| 127 | 1.4.2.1.1 | **Repurpose text from existing training materials** | 0.38d | 2009-03-11 10:30 | 2009-03-11 14:30 |  |  |  |  | 0d |  |  | 3h | 375 |
| 128 | 1.4.2.1.1.1 | Repurpose existing text from training documentation | 1h | 2009-03-11 10:30 | 2009-03-11 11:30 | 124 |  |  |  | 0d |  | WH_PM | 1h | 125 |
| 129 | 1.4.2.1.1.2 | Repurpose existing text from Freelance training presentations | 1h | 2009-03-11 11:30 | 2009-03-11 13:30 | 128 |  |  |  | 0d |  | WH_PM | 1h | 125 |
| 130 | 1.4.2.1.1.3 | Repurpose text from other existing documentation | 1h | 2009-03-11 13:30 | 2009-03-11 14:30 | 129 |  |  |  | 0d |  | WH_PM | 1h | 125 |
| 131 | 1.4.2.1.2 | **Create new text** | 1d | 2009-03-11 10:30 | 2009-03-12 10:30 |  |  |  |  | 16.75d |  |  | 16h | 1,000 |
| 132 | 1.4.2.1.2.1 | Write learning objectives | 0.5h | 2009-03-11 10:30 | 2009-03-11 11:00 | 124 |  |  |  | 16.75d | 0d | Lotus_SME1; WH_ID_Sr | 1h | 62.5 |
| 133 | 1.4.2.1.2.2 | Write motivational text | 2h | 2009-03-11 11:00 | 2009-03-11 14:00 | 132 |  |  |  | 16.75d | 0d | Lotus_SME1; WH_ID_Sr | 4h | 250 |
| 134 | 1.4.2.1.2.3 | Write text for training interactions and feedback | 2h | 2009-03-11 14:00 | 2009-03-11 16:00 | 133 |  |  |  | 16.75d | 0d | Lotus_SME1; WH_ID_Sr | 4h | 250 |
| 135 | 1.4.2.1.2.4 | Write assessment questions and feedback | 2.5h | 2009-03-11 16:00 | 2009-03-12 09:30 | 134 |  |  |  | 16.75d | 0d | Lotus_SME1; WH_ID_Sr | 5h | 312.5 |
| 136 | 1.4.2.1.2.5 | Write transitional text | 1h | 2009-03-12 09:30 | 2009-03-12 10:30 | 135 |  |  |  | 16.75d | 0d | Lotus_SME1; WH_ID_Sr | 2h | 125 |
| 137 | 1.4.2.2 | **Lesson 2: Introduction to Distributed Learning** | 1.62d | 2009-03-11 14:30 | 2009-03-13 10:30 |  | 1998-10-26 08:00 | 1998-10-26 17:00 | 1d | 0d |  |  | 21h | 1,625 |
| 138 | 1.4.2.2.1 | **Repurpose text from existing training materials** | 0.62d | 2009-03-11 14:30 | 2009-03-12 10:30 |  |  |  |  | 0d |  |  | 5h | 625 |
| 139 | 1.4.2.2.1.1 | Repurpose existing text from training documentation | 2h | 2009-03-11 14:30 | 2009-03-11 16:30 | 130 |  |  |  | 0d |  | WH_PM | 2h | 250 |
| 140 | 1.4.2.2.1.2 | Repurpose existing text from Freelance training presentations | 2h | 2009-03-11 16:30 | 2009-03-12 09:30 | 139 |  |  |  | 0d |  | WH_PM | 2h | 250 |
| 141 | 1.4.2.2.1.3 | Repurpose text from other existing documentation | 1h | 2009-03-12 09:30 | 2009-03-12 10:30 | 140 |  |  |  | 0d |  | WH_PM | 1h | 125 |
| 142 | 1.4.2.2.2 | **Create new text** | 1d | 2009-03-12 10:30 | 2009-03-13 10:30 |  |  |  |  | 16.75d |  |  | 16h | 1,000 |
| 143 | 1.4.2.2.2.1 | Write learning objectives | 0.5h | 2009-03-12 10:30 | 2009-03-12 11:00 | 136 |  |  |  | 16.75d | 0d | Lotus_SME1; WH_ID_Sr | 1h | 62.5 |
| 144 | 1.4.2.2.2.2 | Write motivational text | 2h | 2009-03-12 11:00 | 2009-03-12 14:00 | 143 |  |  |  | 16.75d | 0d | Lotus_SME1; WH_ID_Sr | 4h | 250 |
| 145 | 1.4.2.2.2.3 | Write text for training interactions and feedback | 2h | 2009-03-12 14:00 | 2009-03-12 16:00 | 144 |  |  |  | 16.75d | 0d | Lotus_SME1; WH_ID_Sr | 4h | 250 |
| 146 | 1.4.2.2.2.4 | Write assessment questions and feedback | 2.5h | 2009-03-12 16:00 | 2009-03-13 09:30 | 145 |  |  |  | 16.75d | 0d | Lotus_SME1; WH_ID_Sr | 5h | 312.5 |
| 147 | 1.4.2.2.2.5 | Write transitional text | 1h | 2009-03-13 09:30 | 2009-03-13 10:30 | 146 |  |  |  | 16.75d | 0d | Lotus_SME1; WH_ID_Sr | 2h | 125 |
| 148 | 1.4.2.3 | **Lesson 3: Introduction to the LearningSpace Product Line** | 2.69d | 2009-03-12 10:30 | 2009-03-16 17:00 |  | 1998-10-26 08:00 | 1998-10-26 17:00 | 1d | 0d |  |  | 34h | 2,562.5 |
| 149 | 1.4.2.3.1 | **Repurpose text from existing training materials** | 0.88d | 2009-03-12 10:30 | 2009-03-13 09:30 |  |  |  |  | 0d |  |  | 7h | 875 |
| 150 | 1.4.2.3.1.1 | Repurpose existing text from training documentation | 3h | 2009-03-12 10:30 | 2009-03-12 14:30 | 141 |  |  |  | 0d |  | WH_PM | 3h | 375 |
| 151 | 1.4.2.3.1.2 | Repurpose existing text from Freelance training presentations | 3h | 2009-03-12 14:30 | 2009-03-13 08:30 | 150 |  |  |  | 0d |  | WH_PM | 3h | 375 |
| 152 | 1.4.2.3.1.3 | Repurpose text from other existing documentation | 1h | 2009-03-13 08:30 | 2009-03-13 09:30 | 151 |  |  |  | 0d |  | WH_PM | 1h | 125 |

| ID | WBS | Task | Duration | Start | Finish | Predecessors | Baseline start | Baseline finish | Baseline duration | Total slack | Free slack | Resources | Work | Cost |
| --- | --- | --- | --- | --- | --- | --- | --- | --- | --- | --- | --- | --- | --- | --- |
| 153 | 1.4.2.3.2 | **Create new text** | 1.69d | 2009-03-13 10:30 | 2009-03-16 17:00 |  |  |  |  | 16.75d |  |  | 27h | 1,687.5 |
| 154 | 1.4.2.3.2.1 | Write learning objectives | 0.5h | 2009-03-13 10:30 | 2009-03-13 11:00 | 147 |  |  |  | 16.75d | 0d | Lotus_SME1; WH_ID_Sr | 1h | 62.5 |
| 155 | 1.4.2.3.2.2 | Write motivational text | 4h | 2009-03-13 11:00 | 2009-03-13 16:00 | 154 |  |  |  | 16.75d | 0d | Lotus_SME1; WH_ID_Sr | 8h | 500 |
| 156 | 1.4.2.3.2.3 | Write text for training interactions and feedback | 4h | 2009-03-13 16:00 | 2009-03-16 11:00 | 155 |  |  |  | 16.75d | 0d | Lotus_SME1; WH_ID_Sr | 8h | 500 |
| 157 | 1.4.2.3.2.4 | Write assessment questions and feedback | 4h | 2009-03-16 11:00 | 2009-03-16 16:00 | 156 |  |  |  | 16.75d | 0d | Lotus_SME1; WH_ID_Sr | 8h | 500 |
| 158 | 1.4.2.3.2.5 | Write transitional text | 1h | 2009-03-16 16:00 | 2009-03-16 17:00 | 157 |  |  |  | 16.75d | 0d | Lotus_SME1; WH_ID_Sr | 2h | 125 |
| 159 | 1.4.2.4 | **Lessons 4 & 5: Competition and Pricing** | 2.88d | 2009-03-13 09:30 | 2009-03-18 08:30 |  | 1998-10-26 08:00 | 1998-10-26 17:00 | 1d | 0d |  |  | 22h | 1,687.5 |
| 160 | 1.4.2.4.1 | **Repurpose text from existing training materials** | 0.62d | 2009-03-13 09:30 | 2009-03-13 15:30 |  |  |  |  | 0d |  |  | 5h | 625 |
| 161 | 1.4.2.4.1.1 | Repurpose existing text from training documentation | 2h | 2009-03-13 09:30 | 2009-03-13 11:30 | 152 |  |  |  | 0d |  | WH_PM | 2h | 250 |
| 162 | 1.4.2.4.1.2 | Repurpose existing text from Freelance training presentations | 2h | 2009-03-13 11:30 | 2009-03-13 14:30 | 161 |  |  |  | 0d |  | WH_PM | 2h | 250 |
| 163 | 1.4.2.4.1.3 | Repurpose text from other existing documentation | 1h | 2009-03-13 14:30 | 2009-03-13 15:30 | 162 |  |  |  | 0d |  | WH_PM | 1h | 125 |
| 164 | 1.4.2.4.2 | **Create new text** | 1.06d | 2009-03-17 08:00 | 2009-03-18 08:30 |  |  |  |  | 16.75d |  |  | 17h | 1,062.5 |
| 165 | 1.4.2.4.2.1 | Write learning objectives | 0.5h | 2009-03-17 08:00 | 2009-03-17 08:30 | 158 |  |  |  | 16.75d | 0d | Lotus_SME1; WH_ID_Sr | 1h | 62.5 |
| 166 | 1.4.2.4.2.2 | Write motivational text | 1h | 2009-03-17 08:30 | 2009-03-17 09:30 | 165 |  |  |  | 16.75d | 0d | Lotus_SME1; WH_ID_Sr | 2h | 125 |
| 167 | 1.4.2.4.2.3 | Write text for training interactions and feedback | 4h | 2009-03-17 09:30 | 2009-03-17 14:30 | 166 |  |  |  | 16.75d | 0d | Lotus_SME1; WH_ID_Sr | 8h | 500 |
| 168 | 1.4.2.4.2.4 | Write assessment questions and feedback | 2h | 2009-03-17 14:30 | 2009-03-17 16:30 | 167 |  |  |  | 16.75d | 0d | Lotus_SME1; WH_ID_Sr | 4h | 250 |
| 169 | 1.4.2.4.2.5 | Write transitional text | 1h | 2009-03-17 16:30 | 2009-03-18 08:30 | 168 |  |  |  | 16.75d | 0d | Lotus_SME1; WH_ID_Sr | 2h | 125 |
| 170 | 1.4.2.5 | **Lesson 6: LearningSpace Solutions Selling** | 4.69d | 2009-03-13 15:30 | 2009-03-20 12:00 |  | 1998-10-26 08:00 | 1998-10-26 17:00 | 1d | 0d |  |  | 49h | 3,687.5 |
| 171 | 1.4.2.5.1 | **Repurpose text from existing training materials** | 1.25d | 2009-03-13 15:30 | 2009-03-17 08:30 |  |  |  |  | 0d |  |  | 10h | 1,250 |
| 172 | 1.4.2.5.1.1 | Repurpose existing text from training documentation | 4h | 2009-03-13 15:30 | 2009-03-16 10:30 | 163 |  |  |  | 0d |  | WH_PM | 4h | 500 |
| 173 | 1.4.2.5.1.2 | Repurpose existing text from Freelance training presentations | 4h | 2009-03-16 10:30 | 2009-03-16 15:30 | 172 |  |  |  | 0d |  | WH_PM | 4h | 500 |
| 174 | 1.4.2.5.1.3 | Repurpose text from other existing documentation | 2h | 2009-03-16 15:30 | 2009-03-17 08:30 | 173 |  |  |  | 0d |  | WH_PM | 2h | 250 |
| 175 | 1.4.2.5.2 | **Create new text** | 2.44d | 2009-03-18 08:30 | 2009-03-20 12:00 |  |  |  |  | 16.75d |  |  | 39h | 2,437.5 |
| 176 | 1.4.2.5.2.1 | Write learning objectives | 0.5h | 2009-03-18 08:30 | 2009-03-18 09:00 | 169 |  |  |  | 16.75d | 0d | Lotus_SME1; WH_ID_Sr | 1h | 62.5 |
| 177 | 1.4.2.5.2.2 | Write motivational text | 2h | 2009-03-18 09:00 | 2009-03-18 11:00 | 176 |  |  |  | 16.75d | 0d | Lotus_SME1; WH_ID_Sr | 4h | 250 |
| 178 | 1.4.2.5.2.3 | Write text for training interactions and feedback | 8h | 2009-03-18 11:00 | 2009-03-19 11:00 | 177 |  |  |  | 16.75d | 0d | Lotus_SME1; WH_ID_Sr | 16h | 1,000 |
| 179 | 1.4.2.5.2.4 | Write assessment questions and feedback | 8h | 2009-03-19 11:00 | 2009-03-20 11:00 | 178 |  |  |  | 16.75d | 0d | Lotus_SME1; WH_ID_Sr | 16h | 1,000 |
| 180 | 1.4.2.5.2.5 | Write transitional text | 1h | 2009-03-20 11:00 | 2009-03-20 12:00 | 179 |  |  |  | 16.75d | 0d | Lotus_SME1; WH_ID_Sr | 2h | 125 |

| ID | WBS | Task | Type | Duration | Start | Finish | Predecessors | Baseline start | Baseline finish | Baseline duration | Total slack | Free slack | Resources | Work | Cost |
| --- | --- | --- | --- | --- | --- | --- | --- | --- | --- | --- | --- | --- | --- | --- | --- |
| 181 | 1.4.2.6 | **Lesson 5: Technical Basics** |  | 4d | 2009-03-17 08:30 | 2009-03-23 08:30 |  | 1998-10-26 08:00 | 1998-10-26 17:00 | 1d | 0d |  |  | 15h | 1,312.5 |
| 182 | 1.4.2.6.1 | **Repurpose text from existing training materials** |  | 0.75d | 2009-03-17 08:30 | 2009-03-17 15:30 |  |  |  |  | 0d |  |  | 6h | 750 |
| 183 | 1.4.2.6.1.1 | Repurpose existing text from training documentation |  | 2h | 2009-03-17 08:30 | 2009-03-17 10:30 | 174 |  |  |  | 0d |  | WH_PM | 2h | 250 |
| 184 | 1.4.2.6.1.2 | Repurpose existing text from Freelance training presentations |  | 2h | 2009-03-17 10:30 | 2009-03-17 13:30 | 183 |  |  |  | 0d |  | WH_PM | 2h | 250 |
| 185 | 1.4.2.6.1.3 | Repurpose text from other existing documentation |  | 2h | 2009-03-17 13:30 | 2009-03-17 15:30 | 184 |  |  |  | 0d |  | WH_PM | 2h | 250 |
| 186 | 1.4.2.6.2 | **Create new text** |  | 0.56d | 2009-03-20 13:00 | 2009-03-23 08:30 |  |  |  |  | 16.75d |  |  | 9h | 562.5 |
| 187 | 1.4.2.6.2.1 | Write learning objectives |  | 0.5h | 2009-03-20 13:00 | 2009-03-20 13:30 | 180 |  |  |  | 16.75d | 0d | Lotus_SME1; WH_ID_Sr | 1h | 62.5 |
| 188 | 1.4.2.6.2.2 | Write motivational text |  | 1h | 2009-03-20 13:30 | 2009-03-20 14:30 | 187 |  |  |  | 16.75d | 0d | Lotus_SME1; WH_ID_Sr | 2h | 125 |
| 189 | 1.4.2.6.2.3 | Write text for training interactions and feedback |  | 1h | 2009-03-20 14:30 | 2009-03-20 15:30 | 188 |  |  |  | 16.75d | 0d | Lotus_SME1; WH_ID_Sr | 2h | 125 |
| 190 | 1.4.2.6.2.4 | Write assessment questions and feedback |  | 1h | 2009-03-20 15:30 | 2009-03-20 16:30 | 189 |  |  |  | 16.75d | 0d | Lotus_SME1; WH_ID_Sr | 2h | 125 |
| 191 | 1.4.2.6.2.5 | Write transitional text |  | 1h | 2009-03-20 16:30 | 2009-03-23 08:30 | 190 |  |  |  | 16.75d |  | Lotus_SME1; WH_ID_Sr | 2h | 125 |
| 192 | 1.4.2.7 | **Review and approve text for asynchronous (self-paced) courses** |  | 4d | 2009-03-17 15:30 | 2009-03-23 15:30 |  | 1998-10-26 08:00 | 1998-10-26 17:00 | 1d | 0d |  |  | 152h | 5,000 |
| 193 | 1.4.2.7.1 | Integrate text into storyboard format |  | 8h | 2009-03-17 15:30 | 2009-03-18 15:30 | 185 | 1998-10-26 08:00 | 1998-10-26 17:00 | 1d | 0d |  | WH_PM | 8h | 1,000 |
| 194 | 1.4.2.7.2 | Proof and edit storyboards |  | 8h | 2009-03-18 08:30 | 2009-03-19 08:30 | 169 | 1998-10-26 08:00 | 1998-10-26 17:00 | 1d | 18.75d |  | WH_Edit1 | 8h | 1,000 |
| 195 | 1.4.2.7.3 | Revise storyboards |  | 8h | 2009-03-18 08:30 | 2009-03-19 08:30 | 169 | 1998-10-26 08:00 | 1998-10-26 17:00 | 1d | 18.75d |  | WH_ID_Sr; Lotus_SME1 | 16h | 1,000 |
| 196 | 1.4.2.7.4 | Submit storyboards for client review | milestone | 0h | 2009-03-18 15:30 | 2009-03-18 15:30 | 193 | 1998-10-26 08:00 | 1998-10-26 17:00 | 1d | 0d |  | WH_PM; Lotus_SME1 |  |  |
| 197 | 1.4.2.7.5 | Client reviews storyboards - initial review |  | 2d | 2009-03-18 15:30 | 2009-03-20 15:30 | 196 | 1998-10-26 08:00 | 1998-10-26 17:00 | 1d | 16d | 0d | Lotus_Reviewer1; Lotus_Reviewer2; Lotus_Reviewer3; Lotus_Reviewer4 | 64h |  |
| 198 | 1.4.2.7.6 | Revise storyboards |  | 8h | 2009-03-20 15:30 | 2009-03-23 15:30 | 197 | 1998-10-26 08:00 | 1998-10-26 17:00 | 1d | 16d |  | WH_ID_Sr; Lotus_SME1 | 16h | 1,000 |
| 199 | 1.4.2.7.7 | Submit storyboards for client review | milestone | 0h | 2009-03-18 15:30 | 2009-03-18 15:30 | 196 | 1998-10-26 08:00 | 1998-10-26 17:00 | 1d | 0d |  | WH_PM; Lotus_SME1 |  |  |
| 200 | 1.4.2.7.8 | Client reviews storyboards - final review |  | 1d | 2009-03-18 15:30 | 2009-03-19 15:30 | 199 | 1998-10-26 08:00 | 1998-10-26 17:00 | 1d | 18d |  | Lotus_Reviewer1; Lotus_Reviewer2; Lotus_Reviewer3; Lotus_Reviewer4 | 32h |  |
| 201 | 1.4.2.7.9 | Update Project Definition |  | 4h | 2009-03-18 15:30 | 2009-03-19 10:30 | 199 | 1998-10-26 08:00 | 1998-10-26 17:00 | 1d | 0d |  | WH_PM | 4h | 500 |
| 202 | 1.4.2.7.10 | Revise Project Plan |  | 4h | 2009-03-19 10:30 | 2009-03-19 15:30 | 201 | 1998-10-26 08:00 | 1998-10-26 17:00 | 1d | 0d |  | WH_PM | 4h | 500 |
| 203 | 1.4.3 | **Construct/repurpose media elements** |  | 9d | 2009-03-18 15:30 | 2009-03-31 15:30 |  | 1998-10-26 08:00 | 1998-10-26 17:00 | 1d | 1d |  |  | 280h | 28,000 |
| 204 | 1.4.3.1 | Specify required media elements (based on detailed design document) |  | 16h | 2009-03-19 15:30 | 2009-03-23 15:30 | 202 | 1998-10-26 08:00 | 1998-10-26 17:00 | 1d | 0d |  | WH_PM | 16h | 2,000 |

| ID | WBS | Task | Type | Duration | Start | Finish | Predecessors | Baseline start | Baseline finish | Baseline duration | Total slack | Free slack | Resources | Work | Cost |
| --- | --- | --- | --- | --- | --- | --- | --- | --- | --- | --- | --- | --- | --- | --- | --- |
| 205 | 1.4.3.2 | **Construct graphic elements** |  | 8d | 2009-03-18 15:30 | 2009-03-30 15:30 |  |  |  |  | 11d |  |  | 80h | 5,000 |
| 206 | 1.4.3.2.1 | Capture system screens |  | 16h | 2009-03-18 15:30 | 2009-03-20 15:30 | 199 | 1998-10-26 08:00 | 1998-10-26 17:00 | 1d | 14d | 0d | Lotus_SME1 | 16h |  |
| 207 | 1.4.3.2.2 | Locate and repurpose existing graphics |  | 24h | 2009-03-20 15:30 | 2009-03-25 15:30 | 206 | 1998-10-26 08:00 | 1998-10-26 17:00 | 1d | 14d |  | Lotus_SME1 | 24h |  |
| 208 | 1.4.3.2.3 | Design and construct new graphics |  | 40h | 2009-03-23 15:30 | 2009-03-30 15:30 | 204 | 1998-10-26 08:00 | 1998-10-26 17:00 | 1d | 11d |  | WH_AD | 40h | 5,000 |
| 209 | 1.4.3.3 | **Construct interactive elements** |  | 5d | 2009-03-23 15:30 | 2009-03-30 15:30 |  |  |  |  | 0d |  |  | 40h | 5,000 |
| 210 | 1.4.3.3.1 | Design modifications |  | 16h | 2009-03-23 15:30 | 2009-03-25 15:30 | 204 |  |  |  | 0d |  | WH_PM | 16h | 2,000 |
| 211 | 1.4.3.3.2 | Development |  | 16h | 2009-03-25 15:30 | 2009-03-27 15:30 | 210 |  |  |  | 0d |  | WH_PM | 16h | 2,000 |
| 212 | 1.4.3.3.3 | Testing |  | 8h | 2009-03-27 15:30 | 2009-03-30 15:30 | 211 |  |  |  | 0d |  | WH_PM | 8h | 1,000 |
| 213 | 1.4.3.4 | **Produce audio** |  | 9d | 2009-03-18 15:30 | 2009-03-31 15:30 |  |  |  |  | 8d |  |  | 84h | 8,500 |
| 214 | 1.4.3.4.1 | **Audio Preproduction** |  | 9d | 2009-03-18 15:30 | 2009-03-31 15:30 |  |  |  |  | 4d |  |  | 28h | 2,500 |
| 215 | 1.4.3.4.1.1 | Prepare audio scripts |  | 8h | 2009-03-30 15:30 | 2009-03-31 15:30 | 212 |  |  |  | 0d |  | WH_PM; Lotus_SME1; WH_ID_Sr | 24h | 2,000 |
| 216 | 1.4.3.4.1.2 | Coordinate recording session |  | 4h | 2009-03-18 15:30 | 2009-03-19 10:30 | 199 |  |  |  | 12.5d | 0d | WH_Audio | 4h | 500 |
| 217 | 1.4.3.4.2 | **Audio Production** |  | 1d | 2009-03-19 10:30 | 2009-03-20 10:30 |  |  |  |  | 12.5d |  |  | 16h | 1,000 |
| 218 | 1.4.3.4.2.1 | Recording session for narration |  | 8h | 2009-03-19 10:30 | 2009-03-20 10:30 | 216 |  |  |  | 12.5d | 0d | WH_Audio; Lotus_SME1 | 16h | 1,000 |
| 219 | 1.4.3.4.3 | **Audio Post-production** |  | 5d | 2009-03-20 10:30 | 2009-03-27 10:30 |  |  |  |  | 12.5d |  |  | 40h | 5,000 |
| 220 | 1.4.3.4.3.1 | Balance audio levels |  | 2h | 2009-03-20 10:30 | 2009-03-20 13:30 | 218 |  |  |  | 12.5d | 0d | WH_Audio | 2h | 250 |
| 221 | 1.4.3.4.3.2 | Digitize audio |  | 6h | 2009-03-20 13:30 | 2009-03-23 10:30 | 220 |  |  |  | 12.5d | 0d | WH_Audio | 6h | 750 |
| 222 | 1.4.3.4.3.3 | Edit, chunk and name audio to the screen level |  | 24h | 2009-03-23 10:30 | 2009-03-26 10:30 | 221 |  |  |  | 12.5d | 0d | WH_Audio | 24h | 3,000 |
| 223 | 1.4.3.4.3.4 | Process audio for Real Audio format |  | 8h | 2009-03-26 10:30 | 2009-03-27 10:30 | 222 |  |  |  | 12.5d |  | WH_Audio | 8h | 1,000 |
| 224 | 1.4.3.5 | **Produce video** |  | 7.5d | 2009-03-18 15:30 | 2009-03-30 10:30 |  |  |  |  | 11.5d |  |  | 60h | 7,500 |
| 225 | 1.4.3.5.1 | **Video Preproduction** |  | 0d | 2009-03-18 15:30 | 2009-03-18 15:30 |  |  |  |  | 11.5d |  |  |  |  |
| 226 | 1.4.3.5.1.1 | Prepare video treatments/scripts | milestone | 0h | 2009-03-18 15:30 | 2009-03-18 15:30 | 199 |  |  |  | 19d |  | WH_ID_Sr |  |  |
| 227 | 1.4.3.5.1.2 | Coordinate video session | milestone | 0h | 2009-03-18 15:30 | 2009-03-18 15:30 | 199 |  |  |  | 11.5d | 0d | WH_Video |  |  |
| 228 | 1.4.3.5.2 | **Video Production** |  | 0d | 2009-03-18 15:30 | 2009-03-18 15:30 |  |  |  |  | 11.5d |  |  |  |  |
| 229 | 1.4.3.5.2.1 | Video Shoot | milestone | 0h | 2009-03-18 15:30 | 2009-03-18 15:30 | 227 |  |  |  | 11.5d | 0d | Lotus_SME1; WH_Video |  |  |

| ID | WBS | Task | Duration | Start | Finish | Predecessors | Baseline start | Baseline finish | Baseline duration | Total slack | Free slack | Resources | Work | Cost |
| --- | --- | --- | --- | --- | --- | --- | --- | --- | --- | --- | --- | --- | --- | --- |
| 230 | 1.4.3.5.3 | **Video Post-production** | 7.5d | 2009-03-18 15:30 | 2009-03-30 10:30 |  |  |  |  | 11.5d |  |  | 60h | 7,500 |
| 231 | 1.4.3.5.3.1 | Digitize and edit video | 40h | 2009-03-18 15:30 | 2009-03-25 15:30 | 229 |  |  |  | 11.5d | 0d | WH_Video | 40h | 5,000 |
| 232 | 1.4.3.5.3.2 | Chunk video to screen level | 12h | 2009-03-25 15:30 | 2009-03-27 10:30 | 231 |  |  |  | 11.5d | 0d | WH_Video | 12h | 1,500 |
| 233 | 1.4.3.5.3.3 | Process video for Real Video format | 8h | 2009-03-27 10:30 | 2009-03-30 10:30 | 232 |  |  |  | 11.5d |  | WH_Video | 8h | 1,000 |
| 234 | 1.4.4 | **Construct LearningSpace courses** | 6.88d | 2009-03-18 15:30 | 2009-03-27 14:30 |  | 1998-10-26 08:00 | 1998-10-26 17:00 | 1d | 12.12d |  |  | 55h | 6,875 |
| 235 | 1.4.4.1 | **Integrate text elements** | 3.12d | 2009-03-18 15:30 | 2009-03-23 16:30 |  |  |  |  | 12.12d |  |  | 25h | 3,125 |
| 236 | 1.4.4.1.1 | Lesson 1 | 5h | 2009-03-18 15:30 | 2009-03-19 11:30 | 199 |  |  |  | 12.12d | 0d | WH_ID_Sr | 5h | 625 |
| 237 | 1.4.4.1.2 | Lesson 2 | 5h | 2009-03-19 11:30 | 2009-03-20 08:30 | 236 |  |  |  | 12.12d | 0d | WH_ID_Sr | 5h | 625 |
| 238 | 1.4.4.1.3 | Lesson 3 | 5h | 2009-03-20 08:30 | 2009-03-20 14:30 | 237 |  |  |  | 12.12d | 0d | WH_ID_Sr | 5h | 625 |
| 239 | 1.4.4.1.4 | Lesson 4 | 5h | 2009-03-20 14:30 | 2009-03-23 10:30 | 238 |  |  |  | 12.12d | 0d | WH_ID_Sr | 5h | 625 |
| 240 | 1.4.4.1.5 | Lesson 5 | 5h | 2009-03-23 10:30 | 2009-03-23 16:30 | 239 |  |  |  | 12.12d | 0d | WH_ID_Sr | 5h | 625 |
| 241 | 1.4.4.2 | **Integrate media elements** | 3.75d | 2009-03-23 16:30 | 2009-03-27 14:30 |  |  |  |  | 12.12d |  |  | 30h | 3,750 |
| 242 | 1.4.4.2.1 | Lesson 1 | 6h | 2009-03-23 16:30 | 2009-03-24 14:30 | 240 |  |  |  | 12.12d | 0d | WH_ID_Sr | 6h | 750 |
| 243 | 1.4.4.2.2 | Lesson 2 | 6h | 2009-03-24 14:30 | 2009-03-25 11:30 | 242 |  |  |  | 12.12d | 0d | WH_ID_Sr | 6h | 750 |
| 244 | 1.4.4.2.3 | Lesson 3 | 6h | 2009-03-25 11:30 | 2009-03-26 09:30 | 243 |  |  |  | 12.12d | 0d | WH_ID_Sr | 6h | 750 |
| 245 | 1.4.4.2.4 | Lesson 4 | 6h | 2009-03-26 09:30 | 2009-03-26 16:30 | 244 |  |  |  | 12.12d | 0d | WH_ID_Sr | 6h | 750 |
| 246 | 1.4.4.2.5 | Lesson 5 | 6h | 2009-03-26 16:30 | 2009-03-27 14:30 | 245 |  |  |  | 12.12d |  | WH_ID_Sr | 6h | 750 |
| 247 | 1.5 | **Testing** | 10d | 2009-03-31 15:30 | 2009-04-14 15:30 |  | 1998-10-26 08:00 | 1998-10-26 17:00 | 1d | 0d |  |  | 97h | 8,125 |
| 248 | 1.5.1 | **Prepare for Testing** | 3d | 2009-03-31 15:30 | 2009-04-03 15:30 |  | 1998-10-26 08:00 | 1998-10-26 17:00 | 1d | 0d |  |  | 24h | 3,000 |
| 249 | 1.5.1.1 | Establish test environment | 8h | 2009-03-31 15:30 | 2009-04-01 15:30 | 215 | 1998-10-26 08:00 | 1998-10-26 17:00 | 1d | 0d |  | WH_PM | 8h | 1,000 |
| 250 | 1.5.1.2 | Install and test hardware/software | 8h | 2009-04-01 15:30 | 2009-04-02 15:30 | 249 | 1998-10-26 08:00 | 1998-10-26 17:00 | 1d | 0d |  | WH_PM | 8h | 1,000 |
| 251 | 1.5.1.3 | Prepare testing database | 8h | 2009-04-02 15:30 | 2009-04-03 15:30 | 250 | 1998-10-26 08:00 | 1998-10-26 17:00 | 1d | 0d |  | WH_PM | 8h | 1,000 |
| 252 | 1.5.2 | **Whittman-Hart completes alpha testing** | 5d | 2009-04-03 15:30 | 2009-04-10 15:30 |  | 1998-10-26 08:00 | 1998-10-26 17:00 | 1d | 0d |  |  | 41h | 5,125 |
| 253 | 1.5.2.1 | Functional requirements testing | 16h | 2009-04-03 15:30 | 2009-04-07 15:30 | 251 | 1998-10-26 08:00 | 1998-10-26 17:00 | 1d | 0d |  | WH_ID_Sr | 16h | 2,000 |
| 254 | 1.5.2.2 | Stress testing/Bug testing | 16h | 2009-04-07 15:30 | 2009-04-09 15:30 | 253 | 1998-10-26 08:00 | 1998-10-26 17:00 | 1d | 0d |  | WH_ID_Sr | 16h | 2,000 |
| 255 | 1.5.2.3 | Revisions | 8h | 2009-04-09 15:30 | 2009-04-10 15:30 | 254 | 1998-10-26 08:00 | 1998-10-26 17:00 | 1d | 0d |  | WH_ID_Sr | 8h | 1,000 |

| ID | WBS | Task | Type | Duration | Start | Finish | Predecessors | Baseline start | Baseline finish | Baseline duration | Total slack | Free slack | Resources | Work | Cost |
| --- | --- | --- | --- | --- | --- | --- | --- | --- | --- | --- | --- | --- | --- | --- | --- |
| 256 | 1.5.2.4 | **Develop documentation** |  | 0.12d | 2009-04-07 15:30 | 2009-04-07 16:30 |  | 1998-10-26 08:00 | 1998-10-26 17:00 | 1d | 4.88d |  |  | 1h | 125 |
| 257 | 1.5.2.4.1 | Installation and setup guide |  | 1h | 2009-04-07 15:30 | 2009-04-07 16:30 | 253 | 1998-10-26 08:00 | 1998-10-26 17:00 | 1d | 4.88d | 0d | WH_ID_Sr | 1h | 125 |
| 258 | 1.5.2.4.2 | User guide | milestone | 0h | 2009-04-07 16:30 | 2009-04-07 16:30 | 257 | 1998-10-26 08:00 | 1998-10-26 17:00 | 1d | 4.88d | 0d | WH_ID_Sr |  |  |
| 259 | 1.5.2.4.3 | Compile support documentation | milestone | 0h | 2009-04-07 16:30 | 2009-04-07 16:30 | 258 | 1998-10-26 08:00 | 1998-10-26 17:00 | 1d | 4.88d |  | WH_ID_Sr |  |  |
| 260 | 1.5.2.5 | Submit beta version to client for beta testing | milestone | 0h | 2009-04-10 15:30 | 2009-04-10 15:30 | 255 | 1998-10-26 08:00 | 1998-10-26 17:00 | 1d | 0d |  | WH_ID_Sr |  |  |
| 261 | 1.5.3 | **Lotus completes beta testing** |  | 2d | 2009-04-10 15:30 | 2009-04-14 15:30 |  | 1998-10-26 08:00 | 1998-10-26 17:00 | 1d | 0d |  |  | 32h |  |
| 262 | 1.5.3.1 | Stress testing/Bug testing |  | 2d | 2009-04-10 15:30 | 2009-04-14 15:30 | 260 | 1998-10-26 08:00 | 1998-10-26 17:00 | 1d | 0d |  | Lotus_Beta Tester1 | 16h |  |
| 263 | 1.5.3.2 | Configuration testing |  | 2d | 2009-04-10 15:30 | 2009-04-14 15:30 | 260 | 1998-10-26 08:00 | 1998-10-26 17:00 | 1d | 0d |  | Lotus_Beta Tester2 | 16h |  |
| 264 | 1.5.3.3 | Client delivers bug/issue log to Whittman-Hart | milestone | 0h | 2009-04-14 15:30 | 2009-04-14 15:30 | 263 | 1998-10-26 08:00 | 1998-10-26 17:00 | 1d | 0d |  | Lotus_Acceptor |  |  |
| 265 | 1.6 | **Final Delivery and Knowledge Transfer** |  | 3d | 2009-04-09 15:30 | 2009-04-14 15:30 |  |  |  |  | 0d |  |  | 36h | 4,500 |
| 266 | 1.6.1 | Whittman-Hart makes final revisions based on bug/issue log |  | 16h | 2009-04-10 15:30 | 2009-04-14 15:30 | 260 | 1998-10-26 08:00 | 1998-10-26 17:00 | 1d | 0d |  | WH_ID_Sr | 16h | 2,000 |
| 267 | 1.6.2 | Master installation CD |  | 4h | 2009-04-09 15:30 | 2009-04-10 10:30 | 254 | 1998-10-26 08:00 | 1998-10-26 17:00 | 1d | 0.5d | 0d | WH_PM | 4h | 500 |
| 268 | 1.6.3 | Master project archive CD |  | 4h | 2009-04-10 10:30 | 2009-04-10 15:30 | 267 | 1998-10-26 08:00 | 1998-10-26 17:00 | 1d | 0.5d | 0d | WH_PM | 4h | 500 |
| 269 | 1.6.4 | Duplicate installation CD and other deliverables |  | 4h | 2009-04-10 15:30 | 2009-04-13 10:30 | 268 | 1998-10-26 08:00 | 1998-10-26 17:00 | 1d | 0.5d | 0d | WH_PM | 4h | 500 |
| 270 | 1.6.5 | Deliver installation CD and other deliverables | milestone | 0h | 2009-04-13 10:30 | 2009-04-13 10:30 | 269 | 1998-10-26 08:00 | 1998-10-26 17:00 | 1d | 0.5d | 0d | WH_PM |  |  |
| 271 | 1.6.6 | Conduct knowledge transfer session |  | 8h | 2009-04-13 10:30 | 2009-04-14 10:30 | 270 |  |  |  | 0.5d | 0d | WH_ID_Sr | 8h | 1,000 |
| 272 | 1.6.7 | Client approves final deliverables | milestone | 0h | 2009-04-14 10:30 | 2009-04-14 10:30 | 271 |  |  |  | 0.5d | 0d | Lotus_Acceptor |  |  |
| 273 | 1.6.8 | 60-day warranty period | milestone | 0h | 2009-04-14 10:30 | 2009-04-14 10:30 | 272 |  |  |  | 0.5d |  |  |  |  |
